# Мярка 6-3-D-007

Schedule from MS Project, 2017-02-06 to 2017-02-23.

## Calendars

- Standard: Mon-Fri 08:00-12:00, 13:00-17:00; Sat-Sun off.

## Schedule

| ID | WBS | Task | Duration | Start | Finish | Predecessors | Total slack | Text1 |
| --- | --- | --- | --- | --- | --- | --- | --- | --- |
| 1 | 1 | **Възстановяване на разрушения защитен бетонов слой на арматурата на плочите** | 14d | 2017-02-06 | 2017-02-23 |  | 0d | 14 дни |
| 2 | 1.1 | Започване на подготовка на строителна площадка - запознаване със схемата на СМР. Установяване на местата на монтаж на възстановителни дейности | 1d | 2017-02-06 | 2017-02-06 |  | 0d | 1 ден |
| 3 | 1.2 | Монтаж на скеле | 1d | 2017-02-07 | 2017-02-07 | 2 | 0d | 1 ден |
| 4 | 1.3 | Отстраняване от повърхността на нанесени покрития | 2d | 2017-02-08 | 2017-02-09 | 3 | 0d | 2 дни |
| 5 | 1.4 | Отстраняване на бетон до достигане на здрава повърхност | 2d | 2017-02-10 | 2017-02-13 | 4 | 0d | 2 дни |
| 6 | 1.5 | Почистване на повърхностите на армир. пръти. | 0.5d | 2017-02-14 | 2017-02-14 | 5 | 0d | 0,5 дни |
| 7 | 1.6 | Преди заготвяне на армироката проверка на всички размери по мярка от място | 0.5d | 2017-02-14 | 2017-02-14 | 6 | 0d | 0,5 дни |
| 8 | 1.7 | Изпълнение на заваръчните дейности - монтаж на армировка и проходка | 3d | 2017-02-15 | 2017-02-17 | 7 | 0d | 3 дни |
| 9 | 1.8 | Приготвяне и полагане на строителни разтвори | 2d | 2017-02-20 | 2017-02-21 | 8 | 0d | 2 дни |
| 10 | 1.9 | Възстановяване на боя | 1d | 2017-02-22 | 2017-02-22 | 9 | 0d | 1 ден |
| 11 | 1.10 | Изчистване на зоните от работната площадка от строителни отпадъци, демонтаж на крепителни елементи, строително скеле, и предпазните огнеупорни материали на тръбопроводите | 1d | 2017-02-23 | 2017-02-23 | 10 | 0d | 1 ден |
